# utepites

Schedule from MS Project, 2010-10-25 to 2010-11-26, costs in Ft.
Rempo Rt

## Calendars

- munkás: Mon-Sat 07:00-12:00, 13:00-15:00; Sun off.

## Resources

| Resource | Rate |
| --- | --- |
| földmérő | 1000 |
| munkás | 700 |
| dömper | 1500 |
| úthenger | 1500 |
| festőautó | 1200 |
| marógép | 2500 |

## Schedule

| ID | Task | Type | Duration | Start | Finish | Predecessors | Total slack | Resources | Work | Cost |
| --- | --- | --- | --- | --- | --- | --- | --- | --- | --- | --- |
| 1 | Nyomvonal kijelölése |  | 2d | 2010-10-25 | 2010-10-27 |  | 0d | földmérő [300%] | 48h | 48,000 |
| 2 | A föld felső rétegének lemarása |  | 6d | 2010-10-27 | 2010-11-04 | 1 | 0d | marógép; munkás [500%] | 288h | 288,000 |
| 3 | Sóder leöntése |  | 4d | 2010-11-04 | 2010-11-09 | 2 | 0d | dömper; munkás [2000%] | 672h | 496,000 |
| 4 | Tömörítés |  | 3d | 2010-11-09 | 2010-11-13 | 3 | 0d | munkás [500%]; úthenger | 144h | 120,000 |
| 5 | Aszfaltozás |  | 6d | 2010-11-13 | 2010-11-20 | 4 | 0d | dömper; úthenger; munkás [1000%] | 576h | 480,000 |
| 6 | !Száradás |  | 2d | 2010-11-13 | 2010-11-16 | 5SS | 0d |  |  |  |
| 7 | Szegély elkészítése |  | 6d | 2010-11-16 | 2010-11-24 | 6 | 0d | munkás [1000%] | 480h | 336,000 |
| 8 | Útburkolati jelek festése |  | 2d | 2010-11-24 | 2010-11-26 | 7 | 0d | munkás [400%]; festőautó | 80h | 64,000 |
| 9 | Átadás | milestone | 0d | 2010-11-26 | 2010-11-26 | 8 | 0d |  |  |  |
